# 2009 support packs - go-live plan

Schedule from MS Project, 2009-12-05 to 2009-12-14.
MIT

## Calendars

- 24 Hours: Mon-Sun 00:00-24:00.

## Schedule

| ID | WBS | Task | Duration | Start | Finish | Predecessors | Total slack | Free slack | Constraint |
| --- | --- | --- | --- | --- | --- | --- | --- | --- | --- |
| 1 | 1 | Backup | 4.5h | 2009-12-05 01:30 | 2009-12-05 06:00 |  | 10.5d | 0d | start no earlier than 2009-12-05 01:30 |
| 2 | 2 | **Pre-update** | 2.12d | 2009-12-05 06:00 | 2009-12-05 23:00 |  | 10.5d |  |  |
| 3 | 2.1 | SAP Kernel, Oracle DB patches | 4h | 2009-12-05 06:00 | 2009-12-05 10:00 | 1 | 10.5d | 0d |  |
| 4 | 2.2 | SPAM/SAINT Update | 1h | 2009-12-05 10:00 | 2009-12-05 11:00 | 3 | 10.5d | 0d |  |
| 5 | 2.3 | Generate DB Stats (DICT, sys, tables) | 12h | 2009-12-05 11:00 | 2009-12-05 23:00 | 4 | 10.5d | 0d |  |
| 6 | 3 | **System Up** | 2.28d | 2009-12-05 23:00 | 2009-12-06 17:15 |  | 10.5d |  |  |
| 7 | 3.1 | Prepare | 16h | 2009-12-05 23:00 | 2009-12-06 15:00 | 5 | 10.5d | 0d |  |
| 8 | 3.2 | Expand DB | 1h | 2009-12-06 15:00 | 2009-12-06 16:00 | 7 | 10.5d | 0d |  |
| 9 | 3.3 | Import transports | 1h | 2009-12-06 16:00 | 2009-12-06 17:00 | 8 | 10.5d | 0d |  |
| 10 | 3.4 | Backup wage types | 0.25h | 2009-12-06 17:00 | 2009-12-06 17:15 | 9 | 22.34d |  |  |
| 11 | 4 | **System up - workbench locked - no transports** | 11.75d | 2009-12-06 17:00 | 2009-12-10 15:00 |  | 10.5d |  |  |
| 12 | 4.1 | Main thru shadow import | 90h | 2009-12-06 17:00 | 2009-12-10 11:00 | 9 | 10.5d | 0d |  |
| 13 | 4.2 | Backup | 4h | 2009-12-10 11:00 | 2009-12-10 15:00 | 12 | 10.5d | 2.62d |  |
| 14 | 5 | **Downtime - from user perspective** | 8d | 2009-12-11 12:00 | 2009-12-14 04:00 |  | 0d |  |  |
| 15 | 5.1 | Run Trial Balance | 1h | 2009-12-11 12:00 | 2009-12-11 13:00 |  | 7.88d |  | start no earlier than 2009-12-11 12:00 |
| 16 | 5.2 | Timeshift jobs | 1h | 2009-12-11 12:00 | 2009-12-11 13:00 | 13 | 7.88d |  | start no earlier than 2009-12-11 12:00 |
| 17 | 5.3 | Lock users | 2h | 2009-12-11 12:00 | 2009-12-11 14:00 |  | 0d |  | start no earlier than 2009-12-11 12:00 |
| 18 | 5.4 | Main: Downtime 1+2 | 30h | 2009-12-11 14:00 | 2009-12-12 20:00 | 17 | 0d |  | start no earlier than 2009-12-11 12:00 |
| 19 | 5.5 | Restore wage types | 0.25h | 2009-12-12 20:00 | 2009-12-12 20:15 | 18 | 3.97d |  |  |
| 20 | 5.6 | Backup - online | 4h | 2009-12-12 20:00 | 2009-12-13 00:00 | 18 | 3.5d |  |  |
| 21 | 5.7 | BSI Updates | 3h | 2009-12-11 14:00 | 2009-12-11 17:00 | 17 | 7.38d |  |  |
| 22 | 5.8 | SGEN ( ABAP Loads) | 8h | 2009-12-12 20:00 | 2009-12-13 04:00 | 18 | 2.88d | 0d |  |
| 23 | 5.9 | Transports (Incl BSI) | 1h | 2009-12-13 04:00 | 2009-12-13 05:00 | 22 | 2.88d |  |  |
| 24 | 5.10 | Generate DB stats (DICT,sys, tables) | 12h | 2009-12-12 20:00 | 2009-12-13 08:00 | 18 | 0d |  |  |
| 25 | 5.11 | RFC Server Setup | 0.25h | 2009-12-12 20:00 | 2009-12-12 20:15 | 18 | 3.97d |  |  |
| 26 | 5.12 | ADS Server pointer | 0.25h | 2009-12-12 20:00 | 2009-12-12 20:15 | 18 | 3.97d |  |  |
| 27 | 5.13 | Trial Balance | 2h | 2009-12-13 08:00 | 2009-12-13 10:00 | 24 | 0d |  |  |
| 28 | 5.14 | Action Log | 1h | 2009-12-13 10:00 | 2009-12-13 11:00 | 27 | 0d |  |  |
| 29 | 5.15 | Contingency | 4h | 2009-12-13 11:00 | 2009-12-13 15:00 | 28 | 0d |  |  |
| 30 | 5.16 | Validation | 4h | 2009-12-13 15:00 | 2009-12-13 19:00 | 29 | 0d |  |  |
| 31 | 5.17 | Go / No-go | 1h | 2009-12-13 19:00 | 2009-12-13 20:00 | 30 | 0d |  |  |
| 32 | 5.18 | Restore - if no-go | 8h | 2009-12-13 20:00 | 2009-12-14 04:00 | 31 | 0d |  |  |
| 33 | 5.19 | Unlock users | 3h | 2009-12-13 20:00 | 2009-12-13 23:00 | 31 | 0.62d |  |  |
| 34 | 5.20 | Job shift | 2h | 2009-12-13 20:00 | 2009-12-13 22:00 | 31 | 0.75d |  |  |
